Schedule from MS Project MPX, 2019-10-18 to 2019-12-03.

## Calendars

- Standard: Mon-Sun 08:00 am-12:00 pm, 01:00 pm-05:00 pm.

## Schedule

| ID | WBS | Task | Duration | Start | Finish | Predecessors | Complete | Text1 |
| --- | --- | --- | --- | --- | --- | --- | --- | --- |
| 1 | 1 | CHL1 Tests (Oportunistic RF On) | 3d | 2019-10-18 | 2019-10-20 |  |  |  |
| 2 | 2 | Tunnel Open | 2d | 2019-10-21 | 2019-10-22 |  |  |  |
| 3 | 3 | **HCO** | 1d | 2019-10-20 | 2019-10-20 |  |  |  |
| 4 | 3.1 | DC Power Box supply Hipot | 1d | 2019-10-20 | 2019-10-20 |  |  | Done |
| 5 | 4 | **Injector Setup** | 17d | 2019-10-18 | 2019-11-03 |  | 22% |  |
| 6 | 4.1 | Gun Electrode 130 keV tests | 3d | 2019-10-18 | 2019-10-20 |  | 100% | Done |
| 7 | 4.2 | Injector PSS certs w/ beam | 1d | 2019-10-21 | 2019-10-21 |  | 100% | Done |
| 8 | 4.3 | **FC1** | 4d | 2019-10-21 | 2019-10-24 | 6 |  |  |
| 9 | 4.3.1 | Cathode Alignment | 2d | 2019-10-21 | 2019-10-22 |  |  |  |
| 10 | 4.3.2 | 4 Laser LLRF Phase Recovery | 1d | 2019-10-22 | 2019-10-22 |  |  |  |
| 11 | 4.3.3 | Beam Setup (Inj Group) | 2d | 2019-10-22 | 2019-10-23 |  |  |  |
| 12 | 4.3.4 | 130 keV Match | 1d | 2019-10-23 | 2019-10-23 |  |  |  |
| 13 | 4.3.5 | Parity Settings for all 4 Lasers | 1d | 2019-10-24 | 2019-10-24 |  |  |  |
| 14 | 4.3.6 | 0L04 FE Test | 1d | 2019-10-24 | 2019-10-24 |  |  |  |
| 15 | 4.4 | **FC2** | 2d | 2019-10-25 | 2019-10-26 | 8 |  |  |
| 16 | 4.4.1 | Beam Setup (FCup 2) | 1d | 2019-10-25 | 2019-10-25 |  |  |  |
| 17 | 4.4.2 | FCup#2 Centering (Current Discrepency Investigation) | 1d | 2019-10-26 | 2019-10-26 |  |  |  |
| 18 | 4.4.3 | 6 MeV Region Match | 1d | 2019-10-26 | 2019-10-26 |  |  |  |
| 19 | 4.4.4 | PQB Setup Verification | 1d | 2019-10-26 | 2019-10-26 |  |  |  |
| 20 | 4.5 | **ILD** | 8d | 2019-10-27 | 2019-11-03 | 15 |  |  |
| 21 | 4.5.1 | Beam Setup (INJ Group) | 2d | 2019-10-27 | 2019-10-28 |  |  |  |
| 22 | 4.5.2 | Inj Matching (Chicane) | 1d | 2019-10-29 | 2019-10-29 |  |  |  |
| 23 | 4.5.3 | PQB Setup Verification | 1d | 2019-10-29 | 2019-10-29 |  |  |  |
| 24 | 4.5.4 | Other ILD Studies | 5d | 2019-10-30 | 2019-11-03 |  |  |  |
| 25 | 5 | SL RF On | 38d | 2019-10-18 | 2019-11-24 |  |  |  |
| 26 | 6 | NL RF On | 37d | 2019-10-19 | 2019-11-24 |  |  |  |
| 27 | 7 | SRF Commisioning (NL Only) | 17d | 2019-10-18 | 2019-11-03 |  |  |  |
| 28 | 8 | C100 FE Measurement w/ GM Tubes | 1d | 2019-11-04 | 2019-11-04 |  |  |  |
| 29 | 9 | Set Energy (RF Push) | 2d | 2019-11-04 | 2019-11-05 | 27 |  |  |
| 30 | 10 | Box Supply Cycling RHEL-7 (Cade) | 1d | 2019-11-04 | 2019-11-04 |  |  |  |

Notes:
- 4: October 17 - 20: DC Power got high potting completed and most shunt checks are finished. Punch list developed. Arc 10 string needs invesigation
- 9: http://opsweb.acc.jlab.org/CSUEApps/atlis/task/18799
- 10: http://opsweb.acc.jlab.org/CSUEApps/atlis/task/19407
- 12: Yves to write ATLis
- 13: http://opsweb.acc.jlab.org/CSUEApps/atlis/task/19670
- 14: http://devweb.acc.jlab.org/CSUEApps/atlis/task/18979
- 17: http://devweb.acc.jlab.org/CSUEApps/atlis/task/19617
- 18: Yves to write ATLis
- 19: http://opsweb.acc.jlab.org/CSUEApps/atlis/task/18793
- 21: Yves to write ATLis
- 22: Yves to write ATLis
- 23: http://opsweb.acc.jlab.org/CSUEApps/atlis/task/18793
- 25: October 18-20: Much of the C30s and C50s brought up. No C100s. https://logbooks.jlab.org/entry/3735406
- 27: October 18-20: 1L25 and 1L20 comissioning began. 1L20 entries: https://logbooks.jlab.org/entry/3735215 https://logbooks.jlab.org/entry/3735228 https://logbooks.jlab.org/entry/3735235 https://logbooks.jlab.org/entry/3735278 https://logbooks.jlab.org/entry/3735282 https://logbooks.jlab.org/entry/3735284 https://logbooks.jlab.org/entry/3735277 1L25 entries: https://logbooks.jlab.org/entry/3735349 https://logbooks.jlab.org/entry/3735417
- 28: Powers Atlis Inc
- 30: http://opsweb.acc.jlab.org/CSUEApps/atlis/atlis.php?load=Task&task_id=19184 / Can be done during RF Push, after DC Power HCO, and before 5 pass spin up

| ID | WBS | Task | Duration | Start | Finish | Predecessors |
| --- | --- | --- | --- | --- | --- | --- |
| 31 | 11 | **5 pass Spin up** | 7d | 2019-11-06 | 2019-11-12 | 29 |
| 32 | 11.1 | **Cold Startup** | 2d | 2019-11-06 | 2019-11-07 |  |
| 33 | 11.1.1 | Beam to 1R | 1d | 2019-11-06 | 2019-11-06 |  |
| 34 | 11.1.2 | Beam to 2R | 1d | 2019-11-07 | 2019-11-07 | 33 |
| 35 | 11.2 | **INJ / 1st pass Setup Tests** | 1d | 2019-11-08 | 2019-11-08 | 32 |
| 36 | 11.2.1 | NL / SL Drift Box Supply Calibration | 1d | 2019-11-08 | 2019-11-08 |  |
| 37 | 11.2.2 | Colinearity Checks | 1d | 2019-11-08 | 2019-11-08 |  |
| 38 | 11.2.3 | Bunch Compresssion using 0L04 | 1d | 2019-11-08 | 2019-11-08 |  |
| 39 | 11.2.4 | Ray Ttrace to 1R | 1d | 2019-11-08 | 2019-11-08 |  |
| 40 | 11.2.5 | Qualify Inj -> NL Match | 1d | 2019-11-08 | 2019-11-08 |  |
| 41 | 11.3 | **6 - ORFP ARC by ARC** | 4d | 2019-11-09 | 2019-11-12 | 35 |
| 42 | 11.3.1 | ARC4 | 1d | 2019-11-09 | 2019-11-09 |  |
| 43 | 11.3.2 | ARC7 | 1d | 2019-11-10 | 2019-11-10 | 42 |
| 44 | 11.3.3 | ARC9 | 1d | 2019-11-11 | 2019-11-11 | 43 |
| 45 | 11.3.4 | 5.5 ORFP Complete | 1d | 2019-11-12 | 2019-11-12 | 44 |
| 46 | 12 | **Beam Tests to Halls - Dates TBD** | 5d | 2019-11-13 | 2019-11-17 | 31 |
| 47 | 12.1 | RF Stress Test | 2d | 2019-11-13 | 2019-11-14 |  |
| 48 | 12.2 | Optimimizing BLM/RF/IC Faults | 1d | 2019-11-13 | 2019-11-13 |  |
| 49 | 12.3 | Spin Dance | 1d | 2019-11-15 | 2019-11-15 |  |
| 50 | 12.4 | Energy Adjustment + Spin Dance | 5d | 2019-11-13 | 2019-11-17 |  |
| 51 | 13 | **Ideas for BS - Dates TBD** | 2d | 2019-11-18 | 2019-11-19 | 46 |
| 52 | 13.1 | Extraction & Match the Halls | 2d | 2019-11-18 | 2019-11-19 |  |
| 53 | 13.2 | Machine Reproducibility After Wein Flips | 1d | 2019-11-18 | 2019-11-18 |  |
| 54 | 13.3 | SL Cryo/Electric Heat Balancing - Tief | 1d | 2019-11-18 | 2019-11-18 |  |
| 55 | 13.4 | C100-6R calibration | 1d | 2019-11-18 | 2019-11-18 |  |
| 56 | 13.5 | LEM Reproducibility | 1d | 2019-11-18 | 2019-11-18 |  |

Notes:
- 32: Atlis Freeman & Aiken
- 33: Thread Beam Hand Phase Tune Energy Phaser
- 34: Thread through SL Hand Phase SL 2E Match SL Phaser
- 36: Tiefenback to develop new ATLis that includes Hall A Arc energy measurment. Yves to to identify contact (Still Doug Higinbotham?)
- 37: Position and timing colinearity for all 4 lasers. Check degree of colinearity through to 1R. Check 4 lasers vs. NL Gang phase. ATLis task needed?
- 38: Use Arc Bunch length measurment process to give max compression using 0L04 (minimum spot size in Arc 1 High dispersive region) at Max energy. Freeman to develop and ATLis task for this.
- 39: Tief / Yves
- 40: Step 1-4 in ORFP. Uses 1L02, 1L06, 1L10 viewers to qualify match from the Injector. Is there a better way? Try INJ FOpt correctors to FOpt to 1R?
- 47: Spin up 5 pass beam to Hall A. Optimize RF and Beam transport with 600 kW in the Machine.
- 48: Perhaps needed to be done during RF stress testing. / May also require re-calibration of BLM? BLMs too sensitive? BLM setup procedure attached to: http://opsweb.acc.jlab.org/CSUEApps/atlis/task/16634
- 53: Rematching Early INJ Testing
- 55: Jay Atlis
- 56: Yves to Write ATLIs Checking Early NL Bypass

| ID | WBS | Task | Duration | Start | Finish |
| --- | --- | --- | --- | --- | --- |
| 57 | 14 | **Physics Start** | 9d | 2019-11-25 | 2019-12-03 |
| 58 | 14.1 | Hall A Physics | 2d | 2019-12-02 | 2019-12-03 |
| 59 | 14.2 | HB Physics | 9d | 2019-11-25 | 2019-12-03 |
| 60 | 14.3 | HC Physics | 9d | 2019-11-25 | 2019-12-03 |
| 61 | 14.4 | HD Physics | 9d | 2019-11-25 | 2019-12-03 |
